# План выполнения работ, ред. 01

Schedule from MS Project, 2020-03-24 to 2020-07-08.
***

## Calendars

- Стандартный: Mon-Fri 09:00-13:00, 14:00-18:00; Sat-Sun off.

## Resources

| Resource | Rate |
| --- | --- |
| Руководитель проекта | 1000 |
| Разработчик системы ORACLE 1 | 700 |
| Разработчик системы WEB | 800 |
| Разработчик контроллеров | 800 |
| Сотрудник исполнителя |  |
| Технический специалист | 400 |
| Специалист по внедрению | 500 |
| Разработчик документации | 250 |
| Архитектор системы, | 800 |
| Разработчик системы Отчетов | 500 |
| Разработчик системы ORACLE 2 | 700 |

## Schedule

| ID | WBS | Task | Duration | Start | Finish | Total slack | Constraint |
| --- | --- | --- | --- | --- | --- | --- | --- |
| 1 | 1 | **Внедрение автоматизированной информационной системы «МедДок»** | 38d | 2020-05-18 | 2020-07-08 |  |  |
| 2 | 1.1 | **Инициализация платформы** | 0d | 2020-05-18 | 2020-05-18 |  |  |
| 3 | 1.1.1 | Регистрация с пустым token | 1d? | 2020-05-18 | 2020-05-18 | 0d | start no earlier than 2020-05-18 |
| 4 | 1.1.2 | Синхронизация Token c мобильным приложением | 1d? | 2020-05-18 | 2020-05-18 | 0d |  |
| 5 | 1.2 | **Регистрация и профили** | 8d | 2020-05-18 | 2020-05-27 |  |  |
| 6 | 1.2.1 | Json получение данных по профилю | 8d? | 2020-05-18 | 2020-05-27 | 0d | start no earlier than 2020-05-18 |
| 7 | 1.2.2 | Изменение данных по профилю | 8d? | 2020-05-18 | 2020-05-27 | 0d | start no earlier than 2020-05-18 |
| 8 | 1.2.3 | Выгрузка/Загрузка фото профиля | 8d? | 2020-05-18 | 2020-05-27 | 0d | start no earlier than 2020-05-18 |
| 9 | 1.2.4 | Список контактов | 8d? | 2020-05-18 | 2020-05-27 | 0d | start no earlier than 2020-05-18 |
| 10 | 1.2.5 | Чтение профиля контакта | 8d? | 2020-05-18 | 2020-05-27 | 0d | start no earlier than 2020-05-18 |
| 11 | 1.2.6 | Редактирование своего профиля | 8d? | 2020-05-18 | 2020-05-27 | 0d | start no earlier than 2020-05-18 |
| 12 | 1.2.7 | Получение списка доступных услуг | 8d? | 2020-05-18 | 2020-05-27 | 0d | start no earlier than 2020-05-18 |
| 13 | 1.2.8 | Создание КИ | 8d? | 2020-05-18 | 2020-05-27 | 0d | start no earlier than 2020-05-18 |
| 14 | 1.2.9 | Список клинических историй (список чатов) | 8d? | 2020-05-18 | 2020-05-27 | 0d | start no earlier than 2020-05-18 |
| 15 | 1.3 | **Чат без дневников и КИ** | 11d | 2020-05-27 | 2020-06-10 |  |  |
| 16 | 1.3.1 | Список сообщений чата с фетчем и фильтром | 1d? | 2020-06-10 | 2020-06-10 | 0d | finish no earlier than 2020-06-10 |
| 17 | 1.3.2 | Ревизия списка Event | 1d? | 2020-06-10 | 2020-06-10 | 0d | finish no earlier than 2020-06-10 |
| 18 | 1.3.3 | Подключение событий Eventer | 1d? | 2020-06-10 | 2020-06-10 | 0d | finish no earlier than 2020-06-10 |
| 19 | 1.3.4 | Отправка сообщения | 1d? | 2020-06-10 | 2020-06-10 | 0d | finish no earlier than 2020-06-10 |
| 20 | 1.3.5 | Отправка вложения с тегом и описанием | 1d? | 2020-06-10 | 2020-06-10 | 0d | finish no earlier than 2020-06-10 |
| 21 | 1.3.6 | Удаление сообщения | 1d? | 2020-06-10 | 2020-06-10 | 0d | finish no earlier than 2020-06-10 |
| 22 | 1.3.7 | Редактирование сообщения | 1d? | 2020-06-10 | 2020-06-10 | 0d | finish no earlier than 2020-06-10 |
| 23 | 1.4 | **Медкарты и КИ** | 6d | 2020-06-10 | 2020-06-17 |  |  |
| 24 | 1.4.1 | Json клинический эпизод | 1d? | 2020-06-10 | 2020-06-10 | 0d |  |
| 25 | 1.4.2 | Изменение данных в КИ | 1d? | 2020-06-10 | 2020-06-10 | 0d |  |
| 26 | 1.4.3 | Добавление сообщения и вложения в КИ | 1d? | 2020-06-10 | 2020-06-10 | 0d |  |
| 27 | 1.4.4 | Список вложений с тегом и мета с поиском | 1d? | 2020-06-10 | 2020-06-10 | 0d |  |
| 28 | 1.4.5 | Просмотр вложений | 1d? | 2020-06-10 | 2020-06-10 | 0d |  |
| 29 | 1.4.6 | Копирование нескольких сообщений в группу КИ | 1d? | 2020-06-10 | 2020-06-10 | 0d |  |
| 30 | 1.4.7 | Копирование изображения в группу КИ | 1d? | 2020-06-10 | 2020-06-10 | 0d |  |
| 31 | 1.4.8 | Json медкарты | 1d? | 2020-06-10 | 2020-06-10 | 0d |  |
| 32 | 1.4.9 | Список заболеваний и список КИ для медкарты | 1d? | 2020-06-10 | 2020-06-10 | 0d |  |
| 33 | 1.4.10 | Редактирование заболевания | 1d? | 2020-06-10 | 2020-06-10 | 0d |  |

| ID | WBS | Task | Duration | Start | Finish | Total slack |
| --- | --- | --- | --- | --- | --- | --- |
| 34 | 1.5 | **Дневник** | 4d | 2020-06-17 | 2020-06-22 |  |
| 35 | 1.5.1 | Создание дневника врачом | 1d? | 2020-06-17 | 2020-06-17 | 0d |
| 36 | 1.5.2 | Заполнение дневника пациентом | 1d? | 2020-06-17 | 2020-06-17 | 0d |
| 37 | 1.6 | **Календарь и уведомления** | 1d | 2020-03-24 | 2020-03-24 | 0d |
| 38 | 1.6.1 | Календарь событий | 1d? | 2020-03-24 | 2020-03-24 | 0d |
| 39 | 1.6.2 | Уведомления | 1d? | 2020-03-24 | 2020-03-24 | 0d |
| 40 | 1.7 | Тариф | 1d? | 2020-05-18 | 2020-05-18 | 0d |
| 41 | 1.8 | Общее тестирование и публикация | 1d? | 2020-05-18 | 2020-05-18 | 0d |
