# План выполнения работ, ред. 01

Schedule from MS Project, 2022-05-30 to 2022-08-11, costs in р..
***

## Calendars

- Стандартный: Mon-Fri 09:00-13:00, 14:00-18:00; Sat-Sun off.

## Resources

| Resource | Rate |
| --- | --- |
| Кропотов | 1600 |
| Еникеев | 2500 |
| Кузнецов | 2500 |
| Чижик | 1600 |
| Сотрудник исполнителя |  |
| Виталик | 500 |
| Филиппов | 1600 |
| Молочников | 2500 |

## Schedule

| ID | WBS | Task | Type | Duration | Start | Finish | Predecessors | Total slack | Free slack | Constraint | Resources | Work | Cost |
| --- | --- | --- | --- | --- | --- | --- | --- | --- | --- | --- | --- | --- | --- |
| 1 | 1 | **Проект Меддок для клиники** |  | 54d? | 2022-05-30 | 2022-08-11 |  | 0d |  |  |  | 1032h | 2,133,600 |
| 2 | 1.1 | Отключение режима СберPay | manual | 1d | 2022-05-30 | 2022-05-30 |  |  |  |  | Кропотов | 8h | 12,800 |
| 3 | 1.2 | **Разработка и подключение видеочата** |  | 5d? | 2022-05-30 | 2022-06-03 |  | 0d |  |  |  | 88h | 205,600 |
| 4 | 1.2.1 | Доступ к камере и микрофону для IOS | manual | 5d | 2022-05-30 | 2022-06-03 |  |  |  | start no earlier than 2022-05-30 | Молочников | 40h | 100,000 |
| 5 | 1.2.2 | Доступ к камере и микрофону для Андроид | manual | 4d | 2022-05-30 | 2022-06-02 |  |  |  | start no earlier than 2022-05-30 | Молочников | 32h | 80,000 |
| 6 | 1.2.3 | Возврат в мобильное приложение после завершения видео консультации |  | 1d | 2022-05-30 | 2022-05-30 |  | 53d |  |  | Чижик | 8h | 12,800 |
| 7 | 1.2.4 | Работа с видеочатом |  | 1d? | 2022-05-30 | 2022-05-30 |  | 53d |  |  | Чижик | 8h | 12,800 |
| 8 | 1.3 | **Интеграция с МИС CRM Soft** |  | 3d? | 2022-05-30 | 2022-06-01 |  | 0d |  |  |  | 56h | 111,200 |
| 9 | 1.3.1 | **1 этап. Добавляем в интеграцию загрузку pdf-файла заключения через XML FTP** |  | 3d? | 2022-05-30 | 2022-06-01 |  | 51d |  |  |  | 32h | 58,400 |
| 10 | 1.3.1.1 | Реализация бэкенд ТЗ на этап 1 |  | 1d | 2022-05-30 | 2022-05-30 |  | 51d | 0d | start no earlier than 2022-05-30 | Кропотов | 8h | 12,800 |
| 11 | 1.3.1.2 | Реализация фронтенд ТЗ на этап 1 |  | 1d | 2022-05-31 | 2022-05-31 | 10 | 51d | 0d | start no earlier than 2022-05-11 | Филиппов | 8h | 12,800 |
| 12 | 1.3.1.3 | Тестирование и внедрение ТЗ на этап 1 |  | 1d | 2022-06-01 | 2022-06-01 | 11 | 51d |  | start no earlier than 2022-05-11 | Кропотов | 8h | 12,800 |
| 13 | 1.3.1.4 | Плохо отображается просмотр PDF (Bold Шрифты) |  | 1d? | 2022-05-30 | 2022-05-30 |  | 53d |  |  | Кузнецов | 8h | 20,000 |
| 14 | 1.3.2 | В процедуре создания пациента после прихода визитов из CRM Soft добавить перепривязку пациента из Меддок на клинику из визитов | manual | 1d | 2022-05-30 | 2022-05-30 |  |  |  |  | Еникеев | 8h | 20,000 |
| 15 | 1.3.3 | Передавать брони на видеочат в CRM Soft | manual | 1d | 2022-05-30 | 2022-05-30 |  |  |  |  | Еникеев | 8h | 20,000 |
| 16 | 1.3.4 | Проверка результатов загрузки визитов и врачей из Медиуса | manual | 1d | 2022-05-30 | 2022-05-30 |  |  |  |  | Кропотов | 8h | 12,800 |
| 17 | 1.4 | **Подготовка и настройка рабочего места администратора клиники и нач меда (CARABI)** |  | 54d? | 2022-05-30 | 2022-08-11 |  | 0d |  |  |  | 624h | 1,207,200 |
| 18 | 1.4.1 | Проектирование и настройка информационных объектов | manual | 26d | 2022-05-30 | 2022-07-04 |  |  |  | start no earlier than 2022-05-30 | Кропотов | 208h | 332,800 |
| 19 | 1.4.2 | Генерация графика работ от Режима работ врача | manual | 1d | 2022-07-05 | 2022-07-05 | 18 |  |  |  | Еникеев | 8h | 20,000 |
| 20 | 1.4.3 | Отправка приглашений пациентам (новым и кто удалил приложение или был без клиники) | manual | 25d | 2022-07-06 | 2022-08-09 | 19, 18 |  |  |  | Еникеев | 200h | 500,000 |
| 21 | 1.4.4 | Организовать в приложении работу с чатами пациентов на основе роли врача |  | 1d? | 2022-08-10 | 2022-08-10 | 20 | 0d |  |  |  |  |  |
| 22 | 1.4.5 | Функция Перепривязка пациента к другой клинике | manual | 1d | 2022-08-11 | 2022-08-11 | 21, 20 |  |  |  | Еникеев | 8h | 20,000 |
| 23 | 1.4.6 | Инструкция для администратора клиники | manual | 23d | 2022-05-30 | 2022-06-29 | 22 |  |  |  | Кропотов | 184h | 294,400 |
| 24 | 1.4.7 | Роль нач. мед. Финансы по консультациям |  | 1d? | 2022-05-30 | 2022-05-30 |  | 53d |  |  | Еникеев | 8h | 20,000 |
| 25 | 1.4.8 | Роль инвестор. Отобрать фин. По подписке |  | 1d? | 2022-05-30 | 2022-05-30 |  | 53d |  |  | Еникеев | 8h | 20,000 |

| ID | WBS | Task | Type | Duration | Start | Finish | Total slack | Resources | Work | Cost |
| --- | --- | --- | --- | --- | --- | --- | --- | --- | --- | --- |
| 26 | 1.5 | **Биллинг** |  | 21d? | 2022-05-30 | 2022-06-27 | 0d |  | 168h | 420,000 |
| 27 | 1.5.1 | Подключение тарифов клиники на сайте | manual | 21d | 2022-05-30 | 2022-06-27 |  | Еникеев | 168h | 420,000 |
| 28 | 1.6 | **Изменение интерфейса пациента на сайте (Мобильное приложение)** |  | 11d? | 2022-05-30 | 2022-06-13 | 9d |  | 40h | 78,400 |
| 29 | 1.6.1 | Разработка формирования чата с Администратором клиники(бэенд) |  | 1d? | 2022-05-30 | 2022-05-30 | 53d | Еникеев | 8h | 20,000 |
| 30 | 1.6.2 | Разработка формирования чата с Администратором Meddoc по расписанию(бэенд) |  | 1d? | 2022-05-30 | 2022-05-30 | 53d | Еникеев | 8h | 20,000 |
| 31 | 1.6.3 | Разработка. Список врачей клиники совместить с моими врачами |  | 1d | 2022-05-30 | 2022-05-30 | 53d | Чижик | 8h | 12,800 |
| 32 | 1.6.4 | Добавить в список врачей график работы с возможностью записи на прием как BestDoctor | manual | 2d | 2022-06-10 | 2022-06-13 |  | Чижик | 16h | 25,600 |
| 33 | 1.7 | **Подготовка и настройка рабочего места врача клиники (Кабинет Meddoc))** |  | 1d? | 2022-05-30 | 2022-05-30 | 0d |  | 48h | 98,400 |
| 34 | 1.7.1 | Приглашение пациента в чат с отправкой SMS. Доктор видит всех пациентов для начала диалога (не только своих). | manual | 1d | 2022-05-30 | 2022-05-30 |  | Еникеев | 8h | 20,000 |
| 35 | 1.7.2 | Роль администратора клиники (отключение вкладки клинического эпизода) | manual | 1d | 2022-05-30 | 2022-05-30 |  | Еникеев; Чижик | 16h | 32,800 |
| 36 | 1.7.3 | Экран режима и графика работы врача. Отдельный пункт, где записи на прием. (Для врачей Meddoc) | manual | 1d | 2022-05-30 | 2022-05-30 |  | Еникеев; Чижик | 16h | 32,800 |
| 37 | 1.7.4 | Добавить в интерфейс врача иконку "Руб" для выставления счета | manual | 1d | 2022-05-30 | 2022-05-30 |  | Чижик | 8h | 12,800 |
| 38 | 1.7.5 | Инструкция для врача клиники | manual | 1d | 2022-05-30 | 2022-05-30 |  |  |  |  |
| 39 | 1.8 | **Исправление ошибок** |  | 1d? | 2022-05-30 | 2022-05-30 |  |  |  |  |
| 40 | 1.8.1 | Убрать СМС, которая всегда приходит врачу Аббасову при создании нового пациента | manual | 1d? | 2022-05-30 | 2022-05-30 |  |  |  |  |
| 41 | 1.8.2 | После выбора диагноза по МКБ исчезают заполненные жалоба и анамнез | manual | 1d? | 2022-05-30 | 2022-05-30 |  |  |  |  |
| 42 | 1.8.3 | Не выводится сообщение от пациента, если приложение работает. Нужно закрыть приложении, чтобы увидеть сообщение в чате | manual | 1d? | 2022-05-30 | 2022-05-30 |  |  |  |  |
| 43 | 1.8.4 | При оплате подписки не у всех всплывает экран оплаты. Тестирование с Пановой | manual | 1d? | 2022-05-30 | 2022-05-30 |  |  |  |  |
| 44 | 1.8.5 | На IOS перестали работать Добавить вложение из телефона. Поменять облако на скрепку |  | 1d? | 2022-05-30 | 2022-05-30 | 53d |  |  |  |
| 45 | 1.9 | Перевести всех врачей и пациентов Эры здоровья на клинику Меддок | manual | 1d? | 2022-05-30 | 2022-05-30 |  |  |  |  |
| 46 | 1.10 | Презентация приложения в клинике Медиус | manual | 1d | 2022-05-30 | 2022-05-30 |  |  |  |  |
