# План выполнения работ, ред. 01

Schedule from MS Project, 2022-05-11 to 2022-07-05, costs in р..
***

## Calendars

- Стандартный: Mon-Fri 09:00-13:00, 14:00-18:00; Sat-Sun off.

## Resources

| Resource | Rate |
| --- | --- |
| Кропотов | 1600 |
| Еникеев | 2500 |
| Кузнецов | 2500 |
| Чижик | 1600 |
| Сотрудник исполнителя |  |
| Виталик | 500 |
| Филиппов | 1600 |
| Молочников | 2500 |

## Schedule

| ID | WBS | Task | Type | Duration | Start | Finish | Predecessors | Total slack | Free slack | Constraint | Resources | Work | Cost |
| --- | --- | --- | --- | --- | --- | --- | --- | --- | --- | --- | --- | --- | --- |
| 1 | 1 | **Проект Меддок для клиники** |  | 39.88d? | 2022-05-11 09:00 | 2022-07-05 17:00 |  | 0d |  |  |  | 214h | 442,300 |
| 2 | 1.1 | **Разработка и подключение видеочата** |  | 19.88d | 2022-05-30 09:00 | 2022-06-24 17:00 |  | 7d |  |  |  | 71h | 156,800 |
| 3 | 1.1.1 | Адроид собрать версию с видеочатом | manual | 4d | 2022-06-16 09:00 | 2022-06-21 18:00 |  |  |  | start no earlier than 2022-06-16 09:00 | Молочников | 32h | 80,000 |
| 4 | 1.1.2 | Сценарии появления карточки по ТЗ |  | 1d | 2022-05-30 09:00 | 2022-05-30 18:00 |  | 23.5d |  |  | Кропотов | 8h | 12,800 |
| 5 | 1.1.3 | Сервер уведомлений для видеозвонков |  | 1d | 2022-05-30 09:00 | 2022-05-30 18:00 |  | 23.5d |  |  | Кузнецов | 8h | 20,000 |
| 6 | 1.1.4 | Сервисы для информировании видезвонков, формирование чатов при записи на прием от списка врачей |  | 4h | 2022-06-22 09:00 | 2022-06-22 13:00 | 3 | 0d |  |  | Еникеев | 4h | 10,000 |
| 7 | 1.1.5 | Реализация DeepLink для вызов приложения с сайтов в Android и IOS |  | 4h | 2022-06-22 14:00 | 2022-06-22 18:00 | 6 | 0d |  |  | Молочников | 4h | 10,000 |
| 8 | 1.1.6 | Возврат в мобильное приложение после завершения видео консультации |  | 6h | 2022-06-23 09:00 | 2022-06-23 16:00 | 7 | 0d |  |  | Чижик | 6h | 9,600 |
| 9 | 1.1.7 | Индикатор статуса записи на видео в чате |  | 2h | 2022-06-23 16:00 | 2022-06-23 18:00 | 8 | 0d |  |  | Чижик | 2h | 3,200 |
| 10 | 1.1.8 | Карточка видео звонка |  | 5h | 2022-06-24 09:00 | 2022-06-24 15:00 | 9 | 0d |  |  | Чижик | 5h | 8,000 |
| 11 | 1.1.9 | Информирование о наступающем видео звонке |  | 2h | 2022-06-24 15:00 | 2022-06-24 17:00 | 10 | 0d |  |  | Чижик | 2h | 3,200 |
| 12 | 1.2 | **Рабочее место врача клиники** |  | 6d | 2022-06-22 14:00 | 2022-06-30 13:00 |  | 0d |  |  |  | 10h | 17,800 |
| 13 | 1.2.1 | Подключение тарифов клиники на сайте | manual | 2h | 2022-06-22 14:00 | 2022-06-22 16:00 | 6 |  |  |  | Еникеев | 2h | 5,000 |
| 14 | 1.2.2 | Перенос в медкарту вложений из чат в нужный тег |  | 3h | 2022-06-22 14:00 | 2022-06-22 17:00 | 6 | 3.38d | 0d |  | Чижик | 3h | 4,800 |
| 15 | 1.2.3 | Поменять разделы медкарты, перенести профиль наверх, объединитиь кнопку добавления в медкарту в нужный тег, файлы первыми |  | 1h | 2022-06-22 17:00 | 2022-06-22 18:00 | 14 | 3.38d | 0d |  | Чижик | 1h | 1,600 |
| 16 | 1.2.4 | Заключение выгружаем из CRM Soft и пациенту, и врачу. Общая медкарта пациента по тегам(Может сделать автоматические ощие разделы) |  | 1d | 2022-06-23 09:00 | 2022-06-23 18:00 | 15 | 3.38d | 0d |  |  |  |  |
| 17 | 1.2.5 | Для каждого чата с пациентом в файлах(Медкарта) автоматически создавать раздел с названием [ДАТА НАЧАЛА ЧАТА/ПРЕДВАРИТЕЛЬНЫЙ ДИАГНОЗ] |  | 1d | 2022-06-24 09:00 | 2022-06-24 18:00 | 16 | 3.38d | 0d |  |  |  |  |
| 18 | 1.2.6 | У врача в списке чатов всегда показывать чат с Администратором. Всегда на первом месте. |  | 1d | 2022-06-27 09:00 | 2022-06-27 18:00 | 17 | 3.38d | 0d |  |  |  |  |
| 19 | 1.2.7 | Вместо двух кнопок загрузки файлов сделать одну (скрепка). |  | 1d | 2022-06-28 09:00 | 2022-06-28 18:00 | 18 | 3.38d | 0d |  |  |  |  |
| 20 | 1.2.8 | Фильтровать загрузку файлов из чата по Пациенту (по умолчанию по пациенту, переключатель все). Выбор тип хранилища (с устройства, из загруженных). В приватное облако, общее облако |  | 1d | 2022-06-29 09:00 | 2022-06-29 18:00 | 19 | 3.38d | 0d |  |  |  |  |
| 21 | 1.2.9 | Продумать более понятный сценарий(кнопку) перехода в клинический эпизод и медкарту пациента |  | 2h | 2022-06-30 09:00 | 2022-06-30 11:00 | 20 | 3.38d | 0d |  | Кропотов | 2h | 3,200 |
| 22 | 1.2.10 | В списке чатов добавлять вложения в медкарту или в КИ. При долгом нажатии открывать меню выбора. Переработать логику добавления файлов в медкарту и КИ |  | 2h | 2022-06-30 11:00 | 2022-06-30 13:00 | 21 | 3.38d |  |  | Чижик | 2h | 3,200 |
| 23 | 1.3 | **Изменение интерфейса пациента на сайте (Мобильное приложение)** |  | 1d | 2022-05-30 09:00 | 2022-05-30 18:00 |  |  |  |  |  | 16h | 25,600 |
| 24 | 1.3.1 | 1. На вкладке «Чаты», удалить меню «+» из верхнего правого угла. Внизу окна разместить кнопку «Создать новый чат». |  | 2h | 2022-06-24 17:00 | 2022-06-27 10:00 | 11 | 5d | 0d |  | Чижик | 2h | 3,200 |
| 25 | 1.3.2 | 2.Изменения на экране Чат(Перенести пункт меню «Создать новый чат» в правое верхнее меню, Разместить кнопку «Видеочат» в нижней панели) |  | 1h | 2022-06-27 10:00 | 2022-06-27 11:00 | 24 | 5d | 0d |  | Чижик | 1h | 1,600 |
| 26 | 1.3.3 | 2.1 Показывать в меню пункт «Дневник», если в клиническом эпизоде есть хотя бы один ИО «Дневник» в статусе «запущен» или «остановлен». Или, для простоты разработки, показывать уведомление пациенту «У вас пока нет дневника наблюдений» (на вопросы по этому |  | 1h | 2022-06-27 11:00 | 2022-06-27 12:00 | 25 | 5d | 0d |  | Чижик | 1h | 1,600 |
| 27 | 1.3.4 | 2.2 Сейчас, если в телефоне на клавиатуре нажать Enter, то сообщение отправляется в чат. Нужно, чтобы после нажатия Enter, в подготавливаемом сообщении, происходил переход курсора на следующую строку. |  | 2h | 2022-06-27 12:00 | 2022-06-27 15:00 | 26 | 5d | 0d |  | Чижик | 2h | 3,200 |
| 28 | 1.3.5 | 3.Изменения в процессе создания нового чата с экрана Чат |  | 4h | 2022-06-27 15:00 | 2022-06-28 10:00 | 27 | 5d | 0d |  | Чижик | 4h | 6,400 |
| 29 | 1.3.6 | 4.Изменения в карточке врача.Карточка открывается в двух местах:Клик на врача в списке врачей,Клик на врача в чате,Убрать телефон и старые значки «Новый чат» и «Запланировать видео чат». Сделать как на картинке:Кнопка «Написать» - функционал «новый чат»Кн |  | 4h | 2022-06-28 10:00 | 2022-06-28 15:00 | 28 | 5d | 0d |  | Чижик | 4h | 6,400 |
| 30 | 1.3.7 | 5.Изменения в процессе создания нового чата с карточки врача |  | 2h | 2022-06-28 15:00 | 2022-06-28 17:00 | 29 | 5d |  |  | Чижик | 2h | 3,200 |

| ID | WBS | Task | Type | Duration | Start | Finish | Predecessors | Total slack | Free slack | Constraint | Resources | Work | Cost |
| --- | --- | --- | --- | --- | --- | --- | --- | --- | --- | --- | --- | --- | --- |
| 31 | 1.4 | **Изменение серверной платформы приложения MedDoc** |  | 2.12d | 2022-06-24 17:00 | 2022-06-28 18:00 |  | 4.88d |  |  |  | 17h | 42,500 |
| 32 | 1.4.1 | Сервис получения списка чатов и список контактов (пациентов, врачей и администраторов) |  | 8h | 2022-06-24 17:00 | 2022-06-27 17:00 | 11 | 4.88d | 0d |  | Кузнецов | 8h | 20,000 |
| 33 | 1.4.2 | Корректировка сервис получения списка сообщений, обновление информации |  | 5h | 2022-06-27 17:00 | 2022-06-28 13:00 | 32 | 4.88d | 0d |  | Кузнецов | 5h | 12,500 |
| 34 | 1.4.3 | Тестирование PUSH уведомлений и открытии чатов при закрытом приложении |  | 4h | 2022-06-28 14:00 | 2022-06-28 18:00 | 33 | 4.88d |  |  | Еникеев | 4h | 10,000 |
| 35 | 1.5 | **График работы врача с текущим расписанием** |  | 2d | 2022-06-23 09:00 | 2022-06-24 18:00 |  | 5.38d |  |  |  |  |  |
| 36 | 1.5.1 | Если клиника – Меддок, то расписание врача каждый врач настраивает сам себе, если НЕМеддок, то расписание только на чтение. При этом в Караби можно поставить галочку врачу "Разрешить редактировать свое расписание"" |  | 1d | 2022-06-23 09:00 | 2022-06-23 18:00 | 15 | 5.38d | 0d |  |  |  |  |
| 37 | 1.5.2 | ТЗ для разработки интерфейса |  | 1d | 2022-06-24 09:00 | 2022-06-24 18:00 | 36 | 5.38d | 0d |  |  |  |  |
| 38 | 1.6 | **Интеграция с МИС CRM Soft** |  | 34.5d? | 2022-05-11 09:00 | 2022-06-28 13:00 |  | 5.38d |  |  |  | 44h | 88,400 |
| 39 | 1.6.1 | Реализация бэкенд ТЗ на этап 1 |  | 1d | 2022-05-30 09:00 | 2022-05-30 18:00 |  | 25.88d |  | start no earlier than 2022-05-30 09:00 | Кропотов | 8h | 12,800 |
| 40 | 1.6.2 | Реализация фронтенд ТЗ на этап 1 |  | 1d | 2022-05-11 09:00 | 2022-05-11 18:00 |  | 38.88d |  | start no earlier than 2022-05-11 09:00 | Филиппов | 8h | 12,800 |
| 41 | 1.6.3 | Тестирование и внедрение ТЗ на этап 1 |  | 1d | 2022-05-11 09:00 | 2022-05-11 18:00 |  | 38.88d |  | start no earlier than 2022-05-11 09:00 | Кропотов | 8h | 12,800 |
| 42 | 1.6.4 | Плохо отображается просмотр PDF (Bold Шрифты) |  | 1d | 2022-05-30 09:00 | 2022-05-30 18:00 |  | 25.88d |  |  | Кузнецов | 8h | 20,000 |
| 43 | 1.6.5 | ТЗ загрузка визитов - поведение в чате |  | 4h | 2022-06-27 09:00 | 2022-06-27 13:00 | 37 | 5.38d | 0d |  | Еникеев | 4h | 10,000 |
| 44 | 1.6.6 | В процедуре создания пациента после прихода визитов из CRM Soft добавить перепривязку пациента из Меддок на клинику из визитов | manual | 1d | 2022-06-27 14:00 | 2022-06-28 13:00 | 43 |  |  |  | Еникеев | 8h | 20,000 |
| 45 | 1.7 | **Администратор клиники** |  | 1d? | 2022-05-30 09:00 | 2022-05-30 18:00 |  |  |  |  | Еникеев; Чижик | 56h | 111,200 |
| 46 | 1.7.1 | Биллинг |  | 1d | 2022-05-30 09:00 | 2022-05-30 18:00 |  | 25.88d |  |  | Еникеев | 8h | 20,000 |
| 47 | 1.7.2 | Подготовить меню администратора с карточками |  | 1d | 2022-06-24 17:00 | 2022-06-27 17:00 | 11 | 0d |  |  | Кропотов | 8h | 12,800 |
| 48 | 1.7.3 | Серверная реализация для режима работы администратора клиники |  | 1d | 2022-06-27 17:00 | 2022-06-28 17:00 | 47 | 0d |  |  | Еникеев | 8h | 20,000 |
| 49 | 1.7.4 | Экран режима и графика работы врача. Отдельный пункт, где записи на прием. (Для врачей Meddoc) | manual | 2d | 2022-06-28 17:00 | 2022-06-30 17:00 | 48 |  |  |  | Чижик | 16h | 25,600 |
| 50 | 1.7.5 | В приложении – чат со всеми пациентами и врачами клиники |  | 1d | 2022-06-30 17:00 | 2022-07-01 17:00 | 49 | 0d |  |  |  |  |  |
| 51 | 1.7.6 | В приложении – администратор может выставить счет любому пациенту клиники, прайс с врачом пока одинаковый, но лучше сделать их раздельными |  | 1d | 2022-07-01 17:00 | 2022-07-04 17:00 | 50 | 0d |  |  |  |  |  |
| 52 | 1.7.7 | **Ошибки** |  | 1d | 2022-07-04 17:00 | 2022-07-05 17:00 | 51 | 0d |  |  |  |  |  |
| 53 | 1.7.7.1 | В Apple – при выделении части текста чата, для переноса в клинический эпизод, не всплывает окно с кнопкой «Переместить» |  | 1d | 2022-07-04 17:00 | 2022-07-05 17:00 | 15 | 0d |  |  |  |  |  |
