# План выполнения работ, ред. 01

Schedule from MS Project, 2022-05-11 to 2022-07-11, costs in р..
***

## Calendars

- Стандартный: Mon-Fri 09:00-13:00, 14:00-18:00; Sat-Sun off.

## Resources

| Resource | Rate |
| --- | --- |
| Кропотов | 1600 |
| Еникеев | 2500 |
| Кузнецов | 2500 |
| Чижик | 1600 |
| Сотрудник исполнителя |  |
| Виталик | 500 |
| Филиппов | 1600 |
| Молочников | 2500 |

## Schedule

| ID | WBS | Task | Type | Duration | Start | Finish | Predecessors | Total slack | Free slack | Constraint | Resources | Work | Cost |
| --- | --- | --- | --- | --- | --- | --- | --- | --- | --- | --- | --- | --- | --- |
| 1 | 1 | **Проект Меддок для клиники** |  | 43.5d? | 2022-05-11 | 2022-07-11 |  | 0d |  |  |  | 214h | 442,300 |
| 2 | 1.1 | **Разработка и подключение видеочата** |  | 25.88d | 2022-05-30 | 2022-07-04 |  | 4.62d |  |  |  | 71h | 156,800 |
| 3 | 1.1.1 | Адроид собрать версию с видеочатом | manual | 4d | 2022-06-16 | 2022-06-21 |  |  |  | start no earlier than 2022-06-16 | Молочников | 32h | 80,000 |
| 4 | 1.1.2 | Сценарии появления карточки по ТЗ |  | 1d | 2022-05-30 | 2022-05-30 |  | 29.5d |  |  | Кропотов | 8h | 12,800 |
| 5 | 1.1.3 | Сервер уведомлений для видеозвонков |  | 1d | 2022-05-30 | 2022-05-30 |  | 29.5d |  |  | Кузнецов | 8h | 20,000 |
| 6 | 1.1.4 | Сервисы для информировании видезвонков, формирование чатов при записи на прием от списка врачей |  | 4h | 2022-06-30 | 2022-06-30 |  | -3.38d | 0d | start no earlier than 2022-06-30 | Еникеев | 4h | 10,000 |
| 7 | 1.1.5 | Реализация DeepLink для вызов приложения с сайтов в Android и IOS |  | 4h | 2022-06-30 | 2022-06-30 | 6 | -3.38d | 0d |  | Молочников | 4h | 10,000 |
| 8 | 1.1.6 | Возврат в мобильное приложение после завершения видео консультации |  | 6h | 2022-07-01 | 2022-07-01 | 7 | -3.38d | 0d |  | Чижик | 6h | 9,600 |
| 9 | 1.1.7 | Индикатор статуса записи на видео в чате |  | 2h | 2022-07-01 | 2022-07-01 | 8 | -3.38d | 0d |  | Чижик | 2h | 3,200 |
| 10 | 1.1.8 | Карточка видео звонка |  | 5h | 2022-07-04 | 2022-07-04 | 9 | -3.38d | 0d |  | Чижик | 5h | 8,000 |
| 11 | 1.1.9 | Информирование о наступающем видео звонке |  | 2h | 2022-07-04 | 2022-07-04 | 10 | -3.38d | 0d |  | Чижик | 2h | 3,200 |
| 12 | 1.2 | **Рабочее место врача клиники** |  | 13d | 2022-06-22 | 2022-07-11 |  | 0d |  |  |  | 10h | 17,800 |
| 13 | 1.2.1 | Подключение тарифов клиники на сайте | manual | 2h | 2022-06-22 | 2022-06-22 | 6 |  |  |  | Еникеев | 2h | 5,000 |
| 14 | 1.2.2 | Перенос в медкарту вложений из чат в нужный тег |  | 3h | 2022-06-30 | 2022-06-30 | 6 | 0d |  |  | Чижик | 3h | 4,800 |
| 15 | 1.2.3 | Поменять разделы медкарты, перенести профиль наверх, объединитиь кнопку добавления в медкарту в нужный тег, файлы первыми |  | 1h | 2022-06-30 | 2022-06-30 | 14 | 0d |  |  | Чижик | 1h | 1,600 |
| 16 | 1.2.4 | Подготовка ТЗ на изменения |  | 1d | 2022-07-01 | 2022-07-01 | 15 | 0d |  |  |  |  |  |
| 17 | 1.2.5 | Заключение выгружаем из CRM Soft и пациенту, и врачу. Общая медкарта пациента по тегам(Может сделать автоматические ощие разделы) |  | 1d | 2022-07-04 | 2022-07-04 | 16 | 0d |  |  |  |  |  |
| 18 | 1.2.6 | Для каждого чата с пациентом в файлах(Медкарта) автоматически создавать раздел с названием [ДАТА НАЧАЛА ЧАТА/ПРЕДВАРИТЕЛЬНЫЙ ДИАГНОЗ] |  | 1d | 2022-07-05 | 2022-07-05 | 17 | 0d |  |  |  |  |  |
| 19 | 1.2.7 | У врача в списке чатов всегда показывать чат с Администратором. Всегда на первом месте. |  | 1d | 2022-07-06 | 2022-07-06 | 18 | 0d |  |  |  |  |  |
| 20 | 1.2.8 | Вместо двух кнопок загрузки файлов сделать одну (скрепка). |  | 1d | 2022-07-07 | 2022-07-07 | 19 | 0d |  |  |  |  |  |
| 21 | 1.2.9 | Фильтровать загрузку файлов из чата по Пациенту (по умолчанию по пациенту, переключатель все). Выбор тип хранилища (с устройства, из загруженных). В приватное облако, общее облако |  | 1d | 2022-07-08 | 2022-07-08 | 20 | 0d |  |  |  |  |  |
| 22 | 1.2.10 | Продумать более понятный сценарий(кнопку) перехода в клинический эпизод и медкарту пациента |  | 2h | 2022-07-11 | 2022-07-11 | 21 | 0d |  |  | Кропотов | 2h | 3,200 |
| 23 | 1.2.11 | В списке чатов добавлять вложения в медкарту или в КИ. При долгом нажатии открывать меню выбора. Переработать логику добавления файлов в медкарту и КИ |  | 2h | 2022-07-11 | 2022-07-11 | 22 | 0d |  |  | Чижик | 2h | 3,200 |
| 24 | 1.3 | **Изменение интерфейса пациента на сайте (Мобильное приложение)** |  | 1d | 2022-05-30 | 2022-05-30 |  |  |  |  |  | 16h | 25,600 |
| 25 | 1.3.1 | 1. На вкладке «Чаты», удалить меню «+» из верхнего правого угла. Внизу окна разместить кнопку «Создать новый чат». |  | 2h | 2022-07-04 | 2022-07-05 | 11 | 2.62d | 0d |  | Чижик | 2h | 3,200 |
| 26 | 1.3.2 | 2.Изменения на экране Чат(Перенести пункт меню «Создать новый чат» в правое верхнее меню, Разместить кнопку «Видеочат» в нижней панели) |  | 1h | 2022-07-05 | 2022-07-05 | 25 | 2.62d | 0d |  | Чижик | 1h | 1,600 |
| 27 | 1.3.3 | 2.1 Показывать в меню пункт «Дневник», если в клиническом эпизоде есть хотя бы один ИО «Дневник» в статусе «запущен» или «остановлен». Или, для простоты разработки, показывать уведомление пациенту «У вас пока нет дневника наблюдений» (на вопросы по этому |  | 1h | 2022-07-05 | 2022-07-05 | 26 | 2.62d | 0d |  | Чижик | 1h | 1,600 |
| 28 | 1.3.4 | 2.2 Сейчас, если в телефоне на клавиатуре нажать Enter, то сообщение отправляется в чат. Нужно, чтобы после нажатия Enter, в подготавливаемом сообщении, происходил переход курсора на следующую строку. |  | 2h | 2022-07-05 | 2022-07-05 | 27 | 2.62d | 0d |  | Чижик | 2h | 3,200 |
| 29 | 1.3.5 | 3.Изменения в процессе создания нового чата с экрана Чат |  | 4h | 2022-07-05 | 2022-07-06 | 28 | 2.62d | 0d |  | Чижик | 4h | 6,400 |
| 30 | 1.3.6 | 4.Изменения в карточке врача.Карточка открывается в двух местах:Клик на врача в списке врачей,Клик на врача в чате,Убрать телефон и старые значки «Новый чат» и «Запланировать видео чат». Сделать как на картинке:Кнопка «Написать» - функционал «новый чат»Кн |  | 4h | 2022-07-06 | 2022-07-06 | 29 | 2.62d | 0d |  | Чижик | 4h | 6,400 |
| 31 | 1.3.7 | 5.Изменения в процессе создания нового чата с карточки врача |  | 2h | 2022-07-06 | 2022-07-06 | 30 | 2.62d |  |  | Чижик | 2h | 3,200 |

| ID | WBS | Task | Type | Duration | Start | Finish | Predecessors | Total slack | Free slack | Constraint | Resources | Work | Cost |
| --- | --- | --- | --- | --- | --- | --- | --- | --- | --- | --- | --- | --- | --- |
| 32 | 1.4 | **Изменение серверной платформы приложения MedDoc** |  | 2.12d | 2022-07-04 | 2022-07-06 |  | 2.5d |  |  |  | 17h | 42,500 |
| 33 | 1.4.1 | Сервис получения списка чатов и список контактов (пациентов, врачей и администраторов) |  | 8h | 2022-07-04 | 2022-07-05 | 11 | 2.5d | 0d |  | Кузнецов | 8h | 20,000 |
| 34 | 1.4.2 | Корректировка сервис получения списка сообщений, обновление информации |  | 5h | 2022-07-05 | 2022-07-06 | 33 | 2.5d | 0d |  | Кузнецов | 5h | 12,500 |
| 35 | 1.4.3 | Тестирование PUSH уведомлений и открытии чатов при закрытом приложении |  | 4h | 2022-07-06 | 2022-07-06 | 34 | 2.5d |  |  | Еникеев | 4h | 10,000 |
| 36 | 1.5 | **График работы врача с текущим расписанием** |  | 2d | 2022-07-01 | 2022-07-04 |  | 3d |  |  |  |  |  |
| 37 | 1.5.1 | Если клиника – Меддок, то расписание врача каждый врач настраивает сам себе, если НЕМеддок, то расписание только на чтение. При этом в Караби можно поставить галочку врачу "Разрешить редактировать свое расписание"" |  | 1d | 2022-07-01 | 2022-07-01 | 15 | 3d | 0d |  |  |  |  |
| 38 | 1.5.2 | ТЗ для разработки интерфейса |  | 1d | 2022-07-04 | 2022-07-04 | 37 | 3d | 0d |  |  |  |  |
| 39 | 1.6 | **Интеграция с МИС CRM Soft** |  | 39.5d | 2022-05-11 | 2022-07-05 |  | 4d |  |  |  | 44h | 88,400 |
| 40 | 1.6.1 | Реализация бэкенд ТЗ на этап 1 |  | 1d | 2022-05-30 | 2022-05-30 |  | 29.5d |  | start no earlier than 2022-05-30 | Кропотов | 8h | 12,800 |
| 41 | 1.6.2 | Реализация фронтенд ТЗ на этап 1 |  | 1d | 2022-05-11 | 2022-05-11 |  | 42.5d |  | start no earlier than 2022-05-11 | Филиппов | 8h | 12,800 |
| 42 | 1.6.3 | Тестирование и внедрение ТЗ на этап 1 |  | 1d | 2022-05-11 | 2022-05-11 |  | 42.5d |  | start no earlier than 2022-05-11 | Кропотов | 8h | 12,800 |
| 43 | 1.6.4 | Плохо отображается просмотр PDF (Bold Шрифты) |  | 1d | 2022-05-30 | 2022-05-30 |  | 29.5d |  |  | Кузнецов | 8h | 20,000 |
| 44 | 1.6.5 | ТЗ загрузка визитов - поведение в чате |  | 4h | 2022-07-05 | 2022-07-05 | 38 | 3d | 0d |  | Еникеев | 4h | 10,000 |
| 45 | 1.6.6 | В процедуре создания пациента после прихода визитов из CRM Soft добавить перепривязку пациента из Меддок на клинику из визитов | manual | 1d | 2022-06-27 | 2022-06-28 | 44 |  |  |  | Еникеев | 8h | 20,000 |
| 46 | 1.7 | **Администратор клиники** |  | 1d? | 2022-05-30 | 2022-05-30 |  |  |  |  | Еникеев; Чижик | 56h | 111,200 |
| 47 | 1.7.1 | Биллинг |  | 1d | 2022-05-30 | 2022-05-30 |  | 29.5d |  |  | Еникеев | 8h | 20,000 |
| 48 | 1.7.2 | Подготовить меню администратора с карточками |  | 1d | 2022-07-04 | 2022-07-05 | 11 | -3.38d | 0d |  | Кропотов | 8h | 12,800 |
| 49 | 1.7.3 | Серверная реализация для режима работы администратора клиники |  | 1d | 2022-07-05 | 2022-07-06 | 48 | -3.38d | 0d |  | Еникеев | 8h | 20,000 |
| 50 | 1.7.4 | Экран режима и графика работы врача. Отдельный пункт, где записи на прием. (Для врачей Meddoc) | manual | 2d | 2022-06-28 | 2022-06-30 | 49 |  |  |  | Чижик | 16h | 25,600 |
| 51 | 1.7.5 | В приложении – чат со всеми пациентами и врачами клиники |  | 1d | 2022-06-30 | 2022-07-01 | 50 | 2.62d | 0d |  |  |  |  |
| 52 | 1.7.6 | В приложении – администратор может выставить счет любому пациенту клиники, прайс с врачом пока одинаковый, но лучше сделать их раздельными |  | 1d | 2022-07-01 | 2022-07-04 | 51 | 2.62d | 0d |  |  |  |  |
| 53 | 1.7.7 | **Ошибки** |  | 2d? | 2022-07-04 | 2022-07-06 | 52 | 2.62d |  |  |  |  |  |
| 54 | 1.7.7.1 | В Apple – при выделении части текста чата, для переноса в клинический эпизод, не всплывает окно с кнопкой «Переместить» |  | 1d | 2022-07-04 | 2022-07-05 | 15 | 3.62d |  |  |  |  |  |
| 59 | 1.7.7.2 | **Рабочее место врача клиники** |  | 1d? | 2022-07-04 | 2022-07-05 |  | 3.62d |  |  |  |  |  |
| 60 | 1.7.7.2.1 | Изменения в интерфейсе Чаты (пункты меню) |  | 1d? | 2022-07-04 | 2022-07-05 |  | 3.62d |  |  |  |  |  |
| 61 | 1.7.7.2.2 | Перенос в медкарту вложений из чат в нужный тег |  | 3h | 2022-07-04 | 2022-07-05 |  | 4.25d |  |  |  |  |  |
| 62 | 1.7.7.2.3 | Поменять разделы медкарты, перенести профиль наверх, объединитиь кнопку добавления в медкарту в нужный тег, файлы первыми |  | 1h | 2022-07-04 | 2022-07-04 |  | 4.5d |  |  |  |  |  |
| 63 | 1.7.7.2.4 | Подготовка ТЗ на изменения |  | 1d | 2022-07-04 | 2022-07-05 |  | 3.62d |  |  |  |  |  |
| 64 | 1.7.7.2.5 | Продумать более понятный сценарий(кнопку) перехода в клинический эпизод и медкарту пациента |  | 2h | 2022-07-04 | 2022-07-05 |  | 4.38d |  |  |  |  |  |
| 65 | 1.7.7.2.6 | В списке чатов добавлять вложения в медкарту или в КИ. При долгом нажатии открывать меню выбора. Переработать логику добавления файлов в медкарту и КИ |  | 2h | 2022-07-04 | 2022-07-05 |  | 4.38d |  |  |  |  |  |
| 66 | 1.7.7.2.7 | Запись на видеочат будет общая для всех чатов |  | 1d? | 2022-07-04 | 2022-07-05 |  | 3.62d |  |  |  |  |  |
| 67 | 1.7.7.2.8 | Заключение выгружаем из CRM Soft и пациенту, и врачу. Общая медкарта пациента по тегам(Может сделать автоматические ощие разделы) |  | 1d | 2022-07-04 | 2022-07-05 |  | 3.62d |  |  |  |  |  |
| 68 | 1.7.7.2.9 | Для каждого чата с пациентом в файлах(Медкарта) автоматически создавать раздел с названием [ДАТА НАЧАЛА ЧАТА/ПРЕДВАРИТЕЛЬНЫЙ ДИАГНОЗ] |  | 1d | 2022-07-04 | 2022-07-05 |  | 3.62d |  |  |  |  |  |
| 69 | 1.7.7.2.10 | Вместо двух кнопок загрузки файлов сделать одну (скрепка). |  | 1d | 2022-07-04 | 2022-07-05 |  | 3.62d |  |  |  |  |  |
| 70 | 1.7.7.2.11 | Подключение тарифов клиники на сайте |  | 2h | 2022-07-04 | 2022-07-05 |  | 4.38d |  |  |  |  |  |
| 71 | 1.7.7.2.12 | Фильтровать загрузку файлов из чата по Пациенту (по умолчанию по пациенту, переключатель все). Выбор тип хранилища (с устройства, из загруженных). В приватное облако, общее облако |  | 1d | 2022-07-04 | 2022-07-05 |  | 3.62d |  |  |  |  |  |

| ID | WBS | Task | Duration | Start | Finish | Total slack |
| --- | --- | --- | --- | --- | --- | --- |
| 72 | 1.7.7.3 | **Изменение серверной платформы приложения MedDoc** | 1d | 2022-07-04 | 2022-07-05 | 3.62d |
| 73 | 1.7.7.3.1 | Сервис получения списка чатов и список контактов (пациентов, врачей и администраторов) | 8h | 2022-07-04 | 2022-07-05 | 3.62d |
| 74 | 1.7.7.3.2 | Корректировка сервис получения списка сообщений, обновление информации | 5h | 2022-07-04 | 2022-07-05 | 4d |
| 75 | 1.7.7.3.3 | Тестирование PUSH уведомлений и открытии чатов при закрытом приложении | 4h | 2022-07-04 | 2022-07-05 | 4.12d |
| 76 | 1.7.7.4 | **График работы врача с текущим расписанием** | 1d | 2022-07-04 | 2022-07-05 | 3.62d |
| 77 | 1.7.7.4.1 | Если клиника – Меддок, то расписание врача каждый врач настраивает сам себе, если НЕМеддок, то расписание только на чтение. При этом в Караби можно поставить галочку врачу "Разрешить редактировать свое расписание"" | 1d | 2022-07-04 | 2022-07-05 | 3.62d |
| 78 | 1.7.7.4.2 | ТЗ для разработки интерфейса | 1d | 2022-07-04 | 2022-07-05 | 3.62d |
| 79 | 1.7.7.5 | **Интеграция с МИС CRM Soft** | 1d? | 2022-07-04 | 2022-07-05 | 3.62d |
| 80 | 1.7.7.5.1 | Плохо отображается просмотр PDF (Bold Шрифты) | 1d | 2022-07-04 | 2022-07-05 | 3.62d |
| 81 | 1.7.7.5.2 | ТЗ загрузка визитов - поведение в чате | 4h | 2022-07-04 | 2022-07-05 | 4.12d |
| 82 | 1.7.7.5.3 | В процедуре создания пациента после прихода визитов из CRM Soft добавить перепривязку пациента из Меддок на клинику из визитов | 1d | 2022-07-04 | 2022-07-05 | 3.62d |
| 83 | 1.7.7.5.4 | Загрузка тарифов клиники из CRM Soft в Караби | 1d? | 2022-07-04 | 2022-07-05 | 3.62d |
| 84 | 1.7.7.5.5 | Если по клинике несколько филиалов, то склеивать все расписания в одно | 1d? | 2022-07-04 | 2022-07-05 | 3.62d |
| 85 | 1.7.7.5.6 | Работа с большими файлами | 1d? | 2022-07-04 | 2022-07-05 | 3.62d |
| 86 | 1.7.7.5.7 | Выгрузка заключений из Меддока в CRM Soft | 1d? | 2022-07-04 | 2022-07-05 | 3.62d |
| 87 | 1.7.7.6 | **Администратор клиники** | 2d? | 2022-07-04 | 2022-07-06 | 2.62d |
| 88 | 1.7.7.6.1 | Биллинг | 1d | 2022-07-04 | 2022-07-05 | 3.62d |
| 89 | 1.7.7.6.2 | Подготовить меню администратора с карточками | 1d | 2022-07-04 | 2022-07-05 | 3.62d |
| 90 | 1.7.7.6.3 | Серверная реализация для режима работы администратора клиники | 1d | 2022-07-04 | 2022-07-05 | 3.62d |
| 91 | 1.7.7.6.4 | Экран режима и графика работы врача. Отдельный пункт, где записи на прием. (Для врачей Meddoc) | 2d | 2022-07-04 | 2022-07-06 | 2.62d |
| 92 | 1.7.7.6.5 | Создание новой роли «Администратор» в приложении Меддок | 1d? | 2022-07-04 | 2022-07-05 | 3.62d |
| 93 | 1.7.7.6.6 | **Раздел Чаты** | 1d? | 2022-07-04 | 2022-07-05 | 3.62d |
| 94 | 1.7.7.6.6.1 | Раздел Чаты. Три подраздела – Пациенты, Врачи, Архив. Отображение профилей в списке чатов | 1d? | 2022-07-04 | 2022-07-05 | 3.62d |
| 95 | 1.7.7.6.6.2 | Раздел Чаты. Отображение профилей Пациента и Врача под ролью Администратор | 1d? | 2022-07-04 | 2022-07-05 | 3.62d |
| 96 | 1.7.7.6.6.3 | Раздел Чаты. Чат под ролью Администратора | 1d? | 2022-07-04 | 2022-07-05 | 3.62d |

| ID | WBS | Task | Duration | Start | Finish | Total slack |
| --- | --- | --- | --- | --- | --- | --- |
| 97 | 1.7.7.6.7 | **Раздел Контакты** | 1d? | 2022-07-04 | 2022-07-05 | 3.62d |
| 98 | 1.7.7.6.7.1 | Раздел Контакты. Отображение пациента и врача в списке контактов | 1d? | 2022-07-04 | 2022-07-05 | 3.62d |
| 99 | 1.7.7.6.7.2 | Раздел Контакты. Поиск контакта | 1d? | 2022-07-04 | 2022-07-05 | 3.62d |
| 100 | 1.7.7.6.8 | **Изменения в ролях Пациента и Врача** | 1d? | 2022-07-04 | 2022-07-05 | 3.62d |
| 101 | 1.7.7.6.8.1 | Добавить в главное меню кнопку «Чат с администратором» | 1d? | 2022-07-04 | 2022-07-05 | 3.62d |
| 102 | 1.7.7.6.8.2 | Администратор в общем списке чатов | 1d? | 2022-07-04 | 2022-07-05 | 3.62d |
| 103 | 1.7.7.6.8.3 | Строка, идентифицирующая чат с Администратором | 1d? | 2022-07-04 | 2022-07-05 | 3.62d |
| 104 | 1.7.7.6.8.4 | Пациент. Чат с администратором в режиме инкогнито | 1d? | 2022-07-04 | 2022-07-05 | 3.62d |
| 105 | 1.7.7.6.8.5 | Врач. Чат с администратором один, но в чате админы общаются под своими ФИО | 1d? | 2022-07-04 | 2022-07-05 | 3.62d |
| 106 | 1.7.7.6.8.6 | Отображение профиля Администратора под ролями Пациента и Врача | 1d? | 2022-07-04 | 2022-07-05 | 3.62d |
| 107 | 1.7.7.6.9 | Скрыть из интерфейса Жалобы пациента | 1d? | 2022-07-04 | 2022-07-05 | 3.62d |
| 108 | 1.7.7.6.10 | В приложении – администратор может выставить счет любому пациенту клиники, прайс с врачом пока одинаковый, но лучше сделать их раздельными | 1d | 2022-07-04 | 2022-07-05 | 3.62d |
| 109 | 1.7.7.7 | **Исправление замечания по результатам тестирования** | 1d? | 2022-07-04 | 2022-07-05 | 3.62d |
| 110 | 1.7.7.7.1 | В интерфейсе врача. В профиле пациента, в разделе «Файлы» нажимаю кнопку загрузки файла в раздел, выбираю файл, заполняю тег, жму кнопку «Загрузить», но в итоге ничего не загружается и не ругается | 1d? | 2022-07-04 | 2022-07-05 | 3.62d |
| 111 | 1.7.7.7.2 | В Окне видеочата, на небольших мобильных устройствах, аватарка и кнопка закрытия окна должны быть всегда полностью видны | 1d? | 2022-07-04 | 2022-07-05 | 3.62d |
| 112 | 1.7.7.7.3 | В интерфейсе врача. Проблема только на десктопе. В профиле пациента, в разделе Файлы нет функции горизонтального скроллинга по тегам. | 1d? | 2022-07-04 | 2022-07-05 | 3.62d |
| 113 | 1.7.7.7.4 | Осталась проблема с вводом в чате на десктопе. Enter и Ctrl+Enter работают одинаково, отправляют сообщение в чат. И в отправленном сообщении не передается перевод каретки. | 1d? | 2022-07-04 | 2022-07-05 | 3.62d |
| 114 | 1.7.7.7.5 | После записи врачом пациента на видеочат врачу в чат пришло два одинаковых уведомления. А пациенту вообще не пришло никакого уведомления | 1d? | 2022-07-04 | 2022-07-05 | 3.62d |
| 115 | 1.7.7.7.6 | В Apple – при выделении части текста чата, для переноса в клинический эпизод, не всплывает окно с кнопкой «Переместить» | 1d | 2022-07-04 | 2022-07-05 | 3.62d |
| 116 | 1.7.7.8 | **Общая функциональность чата** | 1d? | 2022-07-04 | 2022-07-05 | 3.62d |
| 117 | 1.7.7.8.1 | Под всеми ролями в чат добавить функцию «Переслать» | 1d? | 2022-07-04 | 2022-07-05 | 3.62d |
