# План выполнения работ, ред. 01

Schedule from MS Project, 2020-03-24 to 2022-06-10.
***

## Calendars

- Стандартный: Mon-Fri 09:00-13:00, 14:00-18:00; Sat-Sun off.

## Resources

| Resource | Rate |
| --- | --- |
| Руководитель проекта | 1000 |
| Разработчик системы ORACLE 1 | 700 |
| Разработчик системы WEB | 800 |
| Разработчик контроллеров | 800 |
| Сотрудник исполнителя |  |
| Технический специалист | 400 |
| Специалист по внедрению | 500 |
| Разработчик документации | 250 |
| Архитектор системы, | 800 |
| Разработчик системы Отчетов | 500 |
| Разработчик системы ORACLE 2 | 700 |

## Schedule

| ID | WBS | Task | Duration | Start | Finish | Predecessors | Total slack | Free slack | Constraint |
| --- | --- | --- | --- | --- | --- | --- | --- | --- | --- |
| 1 | 1 | **Проект Меддок для клиники** | 579d? | 2020-03-24 | 2022-06-10 |  | 0d |  |  |
| 2 | 1.1 | Подключить домены med-doc.me | 1d | 2022-04-11 | 2022-04-11 |  | 41d |  | start no earlier than 2022-04-11 |
| 3 | 1.2 | Создание майнд-карты проекта Меддок для клиники | 1d | 2022-04-11 | 2022-04-11 |  | 41d |  | start no earlier than 2022-04-11 |
| 4 | 1.3 | **Подключение ЮКассы** | 542d | 2020-03-24 | 2022-04-20 |  | 37d |  |  |
| 5 | 1.3.1 | **Согласование с Юкассой** | 5d | 2022-04-11 | 2022-04-15 |  | 37d |  |  |
| 6 | 1.3.1.1 | Заполнение заявки Меддок | 1d | 2022-04-11 | 2022-04-11 |  | 37d | 0d | start no earlier than 2022-04-11 |
| 7 | 1.3.1.2 | Оформление партнерского подключения Меддок | 1d | 2022-04-12 | 2022-04-12 | 6 | 37d | 0d | start no earlier than 2022-04-12 |
| 8 | 1.3.1.3 | Добавить на сайт стоимость подписки | 1d | 2022-04-13 | 2022-04-13 | 7 | 37d | 0d |  |
| 9 | 1.3.1.4 | Заполнение заявки Эра здоровья | 1d | 2022-04-14 | 2022-04-14 | 8 | 37d | 0d |  |
| 10 | 1.3.1.5 | Добавить на сайт, в карточку врача, реквизиты и контакты клиники | 1d | 2022-04-15 | 2022-04-15 | 9 | 37d | 0d |  |
| 11 | 1.3.2 | **Разработка интеграции через API ЮКассы** | 542d | 2020-03-24 | 2022-04-20 |  | 37d |  |  |
| 12 | 1.3.2.1 | Создание ТЗ разработчику | 1d | 2022-04-18 | 2022-04-18 | 10 | 37d | 0d |  |
| 13 | 1.3.2.2 | Разработка подключения тестового магазина | 1d | 2022-04-19 | 2022-04-19 | 12 | 37d | 0d |  |
| 14 | 1.3.2.3 | Разработка подключения боевого магазина для мультикассы | 1d | 2022-04-20 | 2022-04-20 | 13 | 37d |  |  |
| 15 | 1.3.2.4 | Отключение режима СберPay | 1d | 2020-03-24 | 2020-03-24 |  | 578d |  |  |
| 16 | 1.4 | **Разработка и подключение видеочата** | 544d? | 2020-03-24 | 2022-04-22 |  | 35d |  |  |
| 17 | 1.4.1 | Подключение видеочата WebRTC | 1d | 2022-04-11 | 2022-04-11 |  | 35d | 0d | start no earlier than 2022-04-11 |
| 18 | 1.4.2 | Доступ к камере и микрофону для IOS | 3d | 2022-04-11 | 2022-04-13 |  | 42d |  | start no earlier than 2022-04-11 |
| 19 | 1.4.3 | Доступ к камере и микрофону для Андроид | 5d | 2022-04-11 | 2022-04-15 |  | 40d |  | start no earlier than 2022-04-11 |
| 20 | 1.4.4 | Проектирование окна видеочата | 3d | 2022-04-12 | 2022-04-14 | 17 | 35d | 0d | start no earlier than 2022-04-11 |
| 21 | 1.4.5 | **График работы врача** | 542d? | 2020-03-24 | 2022-04-20 |  | 37d |  |  |
| 22 | 1.4.5.1 | Настройка информационных объектов | 1d | 2022-04-15 | 2022-04-15 | 20 | 35d | 0d | start no earlier than 2022-04-11 |
| 23 | 1.4.5.2 | Разработка бэкенд | 2d | 2022-04-18 | 2022-04-19 | 22 | 35d | 0d |  |
| 24 | 1.4.5.3 | Разработка фронтенд | 1d | 2022-04-20 | 2022-04-20 | 23 | 35d | 0d |  |
| 25 | 1.4.5.4 | Генерация графика работ от Режима работ врача | 1d? | 2020-03-24 | 2020-03-24 |  | 578d |  |  |
| 26 | 1.4.5.5 | Отправка записи на прием в бронирование клиники | 1d? | 2020-03-24 | 2020-03-24 |  | 578d |  |  |
| 27 | 1.4.6 | Добавление функции видеочата в интерфейс врача и пациента | 2d | 2022-04-21 | 2022-04-22 | 24 | 35d |  | start no earlier than 2022-04-11 |

| ID | WBS | Task | Duration | Start | Finish | Predecessors | Total slack | Free slack | Constraint |
| --- | --- | --- | --- | --- | --- | --- | --- | --- | --- |
| 28 | 1.5 | **Интеграция файлов-заключений и файлов-исследований из МИС CRM Soft** | 23d? | 2022-05-11 | 2022-06-10 |  | 0d |  |  |
| 29 | 1.5.1 | **1 этап. Оставляем всё как есть, добавляем в интеграцию загрузку pdf-файла заключения через XML FTP** | 5d? | 2022-05-11 | 2022-05-17 |  | 0d |  |  |
| 30 | 1.5.1.1 | Составление и согласование ТЗ CRM SOFT на этап 1 | 1d | 2022-05-11 | 2022-05-11 |  | 0d |  | start no earlier than 2022-05-11 |
| 31 | 1.5.1.2 | Составление ТЗ Meddoc на этап 1 | 1d? | 2022-05-12 | 2022-05-12 | 30 | 0d |  |  |
| 32 | 1.5.1.3 | Реализация бэкенд ТЗ на этап 1 | 1d | 2022-05-13 | 2022-05-13 | 31 | 0d |  | start no earlier than 2022-05-11 |
| 33 | 1.5.1.4 | Реализация фронтенд ТЗ на этап 1 | 1d | 2022-05-16 | 2022-05-16 | 32 | 0d |  | start no earlier than 2022-05-11 |
| 34 | 1.5.1.5 | Тестирование и внедрение ТЗ на этап 1 | 1d | 2022-05-17 | 2022-05-17 | 33 | 0d |  | start no earlier than 2022-05-11 |
| 35 | 1.5.2 | **2 этап. Удаление обмена через XML FTP по всем данным, перенос старого функционала с FTP на HTTP, добавление загрузки pdf-файла заключения через HTTP** | 11d? | 2022-05-18 | 2022-06-01 |  | 0d |  |  |
| 36 | 1.5.2.1 | Составление и согласование ТЗ на этап 2 | 3d | 2022-05-18 | 2022-05-20 | 34 | 0d |  | start no earlier than 2022-05-11 |
| 37 | 1.5.2.2 | Составление ТЗ Meddoc на этап 2 | 1d? | 2022-05-23 | 2022-05-23 | 36 | 0d |  |  |
| 38 | 1.5.2.3 | Реализация бэкенд ТЗ на этап 2 | 5d | 2022-05-24 | 2022-05-30 | 37 | 0d |  |  |
| 39 | 1.5.2.4 | Реализация фронтенд ТЗ на этап 2 | 1d | 2022-05-31 | 2022-05-31 | 38 | 0d |  | start no earlier than 2022-05-11 |
| 40 | 1.5.2.5 | Тестирование и внедрение ТЗ на этап 2 | 1d | 2022-06-01 | 2022-06-01 | 39 | 0d |  | start no earlier than 2022-05-11 |
| 41 | 1.5.3 | **3 этап. Добавить загрузку больших файлов МРТ-исследований** | 7d? | 2022-06-02 | 2022-06-10 |  | 0d |  |  |
| 42 | 1.5.3.1 | Составление и согласование ТЗ на этап 3 | 2d | 2022-06-02 | 2022-06-03 | 40 | 0d |  |  |
| 43 | 1.5.3.2 | Составление ТЗ Meddoc на этап 3 | 1d? | 2022-06-06 | 2022-06-06 | 42 | 0d |  |  |
| 44 | 1.5.3.3 | Реализация бэкенд ТЗ на этап 3 | 2d | 2022-06-07 | 2022-06-08 | 43 | 0d |  |  |
| 45 | 1.5.3.4 | Реализация фронтенд ТЗ на этап 3 | 1d | 2022-06-09 | 2022-06-09 | 44 | 0d |  |  |
| 46 | 1.5.3.5 | Тестирование и внедрение ТЗ на этап 3 | 1d | 2022-06-10 | 2022-06-10 | 45 | 0d |  |  |
| 47 | 1.6 | **Прайс-листы клиник** | 1d? | 2020-03-24 | 2020-03-24 |  | 578d |  |  |
| 48 | 1.6.1 | Выставление прайсов по специальности? | 1d? | 2020-03-24 | 2020-03-24 |  | 578d |  |  |
| 49 | 1.6.2 | Переключение прайс-листов от стандартных на прай-лист врача клиники | 1d? | 2020-03-24 | 2020-03-24 |  | 578d |  |  |
| 50 | 1.7 | **Подготовка и настройка рабочего места администратора клиники** | 3d? | 2022-04-25 | 2022-04-27 |  | 30d |  |  |
| 51 | 1.7.1 | Проектирование и настройка информационных объектов | 1d | 2022-04-25 | 2022-04-25 |  | 30d | 0d | start no earlier than 2022-04-25 |
| 52 | 1.7.2 | Отправка приглашений пациентам (новым и кто удалил приложение или был без клиники) | 1d? | 2022-04-26 | 2022-04-26 | 51 | 30d | 0d |  |
| 53 | 1.7.3 | Инструкция для администратора клиники | 1d | 2022-04-27 | 2022-04-27 | 52 | 30d | 0d |  |

| ID | WBS | Task | Duration | Start | Finish | Predecessors | Total slack | Free slack | Constraint |
| --- | --- | --- | --- | --- | --- | --- | --- | --- | --- |
| 54 | 1.8 | **Биллинг** | 551d? | 2020-03-24 | 2022-05-03 |  | 28d |  |  |
| 55 | 1.8.1 | Актуализация закадки биллинга у врача и пациента. ТЗ | 1d? | 2020-03-24 | 2020-03-24 |  | 578d |  |  |
| 56 | 1.8.2 | Реализация закладок биллинга | 1d? | 2020-03-24 | 2020-03-24 |  | 578d |  |  |
| 57 | 1.8.3 | Подготовка тарифов клиники по предоставлению консультаций в ИС | 1d | 2022-04-29 | 2022-04-29 |  | 28d | 0d | start no earlier than 2022-04-29 |
| 58 | 1.8.4 | Подключение тарифов клиники на сайте | 2d | 2022-05-02 | 2022-05-03 | 57 | 28d |  |  |
| 59 | 1.9 | Создание почтового ящика info@med-doc.me | 1d | 2022-04-29 | 2022-04-29 |  | 30d |  | start no earlier than 2022-04-29 |
| 60 | 1.10 | **Изменение интерфейса пациента на сайте** | 6d? | 2022-05-13 | 2022-05-20 |  | 14d |  |  |
| 61 | 1.10.1 | Проектирование сценария пациента без чата. Отправка запросов - Чат, Видео, Личный визит | 2d | 2022-05-13 | 2022-05-16 |  | 14d | 0d | start no earlier than 2022-05-13 |
| 62 | 1.10.2 | Проектирование создания нового обращения от списка врачей по специальностям | 1d? | 2022-05-17 | 2022-05-17 | 61 | 14d | 0d |  |
| 63 | 1.10.3 | Разработка бэкенд | 1d | 2022-05-18 | 2022-05-18 | 62 | 14d | 0d |  |
| 64 | 1.10.4 | Разработка фронтенд | 2d | 2022-05-19 | 2022-05-20 | 63 | 14d | 0d |  |
| 65 | 1.11 | **Подготовка и настройка рабочего места врача клиники** | 549d? | 2020-03-24 | 2022-04-29 |  | 30d |  |  |
| 66 | 1.11.1 | Приглашение пациента в чат с отправкой SMS | 1d? | 2020-03-24 | 2020-03-24 |  | 578d |  |  |
| 67 | 1.11.2 | Роль администратора клиники (отключение клинического эпизода) | 1d? | 2020-03-24 | 2020-03-24 |  | 578d |  |  |
| 68 | 1.11.3 | Экран режима и графика работы врача. Отдельный пункт, где записи на прием | 1d? | 2020-03-24 | 2020-03-24 |  | 578d |  |  |
| 69 | 1.11.4 | Дежурные врачи по графику дежурства | 1d? | 2020-03-24 | 2020-03-24 |  | 578d |  |  |
| 70 | 1.11.5 | Проектирование и настройка информационных объектов | 1d | 2022-04-28 | 2022-04-28 | 53 | 30d | 0d |  |
| 71 | 1.11.6 | Инструкция для врача клиники | 1d | 2022-04-29 | 2022-04-29 | 70 | 30d |  |  |
| 72 | 1.12 | **Презентация приложения в клиниках** | 1d | 2022-05-23 | 2022-05-23 |  | 14d |  |  |
| 73 | 1.12.1 | Презентация приложения в клинике Медиус | 1d | 2022-05-23 | 2022-05-23 | 64 | 14d |  |  |
